# 施工横道图

Schedule from MS Project, 2006-05-01 to 2008-03-31.
syj
网络图910×297,缩放比例54%

## Calendars

- 施工日历: Mon-Sun 08:00-12:00, 13:00-17:00.

## Schedule

| ID | Task | Duration | Start | Finish | Predecessors | Total slack | Free slack | Constraint |
| --- | --- | --- | --- | --- | --- | --- | --- | --- |
| 1 | 1.施工准备(地表加固，地表降水) | 31d | 2006-05-01 | 2006-05-31 |  | 0d |  | start no earlier than 2006-05-01 |
| 2 | 2.南市站施工 | 654d | 2006-06-01 | 2008-03-15 |  | 16d |  | start no earlier than 2006-06-01 |
| 3 | 2.1车站一期围挡及道路明挖 | 10d | 2006-06-01 | 2006-06-10 | 1 | 0d |  | start no earlier than 2006-06-01 |
| 4 | 2.2车站一期围护桩结构施工 | 40d | 2006-06-11 | 2006-07-20 | 3 | 0d |  | start no earlier than 2006-06-11 |
| 5 | 2.3车站一期围护桩桩头凿出 | 5d | 2006-07-21 | 2006-07-25 | 4 | 0d |  | start no earlier than 2006-07-21 |
| 6 | 2.4车站一期冠梁及垫梁施工 | 15d | 2006-07-26 | 2006-08-09 | 5 | 0d |  | start no earlier than 2006-07-26 |
| 7 | 2.5车站一期军用梁拼装架设 | 17d | 2006-08-10 | 2006-08-26 | 6 | 0d |  | start no earlier than 2006-07-26 |
| 8 | 2.6铺设桥面板、恢复一期交通 | 5d | 2006-08-27 | 2006-08-31 | 7 | 0d |  | start no earlier than 2006-08-10 |
| 9 | 2.7车站二期围挡及道路明挖 | 10d | 2006-09-01 | 2006-09-10 | 8 | 0d |  | start no earlier than 2006-08-15 |
| 10 | 2.8二期围护桩结构施工 | 40d | 2006-09-11 | 2006-10-20 | 9 | 0d |  | start no earlier than 2006-08-25 |
| 11 | 2.9车站二期围护桩桩头凿出 | 5d | 2006-10-21 | 2006-10-25 | 10 | 0d |  | start no earlier than 2006-10-04 |
| 12 | 2.10车站二期围挡内冠梁及垫梁施工 | 15d | 2006-10-26 | 2006-11-09 | 11 | 0d |  | start no earlier than 2006-10-09 |
| 13 | 2.11车站二期军用梁架设拼装 | 16d | 2006-11-10 | 2006-11-25 | 12 | 0d |  | start no earlier than 2006-11-10 |
| 14 | 2.12铺设桥面板、恢复交通 | 5d | 2006-11-26 | 2006-11-30 | 13 | 0d |  | start no earlier than 2006-11-26 |
| 15 | 2.13主体结构盖挖 | 304d | 2006-12-01 | 2007-09-30 | 14 | 0d |  | start no earlier than 2006-12-01 |
| 16 | 2.14主体结构施工 | 304d | 2007-01-01 | 2007-10-31 | 15SS+31d | 0d |  | start no earlier than 2007-01-01 |
| 17 | 2.15主体结构顶板防水层制作 | 10d | 2007-11-01 | 2007-11-10 | 16 | 0d |  |  |
| 18 | 2.16主体结构顶板回填、恢复交通 | 6d | 2007-11-11 | 2007-11-16 | 17 | 0d |  |  |
| 19 | 2.17三期围挡及附属围护桩结构施工 | 30d | 2007-11-17 | 2007-12-16 | 18 | 0d |  |  |
| 20 | 2.18附属结构明挖法开挖 | 16d | 2007-12-17 | 2008-01-01 | 19 | 0d |  |  |
| 21 | 2.19附属结构主体结构施工 | 50d | 2008-01-02 | 2008-02-20 | 20 | 0d |  |  |
| 22 | 2.20附属结构顶板防水层施工 | 11d | 2008-02-21 | 2008-03-02 | 21 | 0d |  |  |
| 23 | 2.21附属结构顶板回填 | 13d | 2008-03-03 | 2008-03-15 | 22 | 0d |  |  |
| 24 | 3.南市站至青年大街站区间施工 | 639d | 2006-06-01 | 2008-02-29 |  | 31d |  | finish no earlier than 2008-02-29 |
| 25 | 3.1区间围挡结构施工 | 10d | 2006-06-01 | 2006-06-10 | 1 | 26d | 0d | start no earlier than 2006-06-01 |
| 26 | 3.2竖井施工 | 20d | 2006-06-11 | 2006-06-30 | 25 | 26d | 12d | start no earlier than 2006-06-01 |
| 27 | 3.3横向通道施工 | 50d | 2006-07-01 | 2006-08-19 | 26 | 15d | 0d | start no earlier than 2006-07-01 |
| 28 | 3.4区间左线隧道施工 | 545d | 2006-08-20 | 2008-02-15 | 27 | 15d | 0d | start no earlier than 2006-08-20 |
| 29 | 3.5区间隧道右线施工 | 530d | 2006-08-20 | 2008-01-31 | 27 | 15d | 0d | start no earlier than 2006-08-20 |
| 30 | 3.6竖井废弃 | 14d | 2008-02-16 | 2008-02-29 | 28, 29 | 15d |  | finish no earlier than 2006-12-31 |
| 31 | 4.竣工验收 | 16d | 2008-03-16 | 2008-03-31 | 23, 30 | 0d |  | start no earlier than 2006-11-01 |
